# Programa IN CHAPELTIQUE

Schedule from MS Project, 2024-06-03 to 2024-08-10.

## Calendars

- Estándar: Mon-Sun 08:00-12:00, 13:00-16:00.

## Schedule

| ID | WBS | Task | Type | Duration | Start | Finish | Predecessors | Total slack | Free slack | Constraint |
| --- | --- | --- | --- | --- | --- | --- | --- | --- | --- | --- |
| 1 | 1 | **Proyecto: SEDE INSTITUTO NACIONAL DE CHAPELTIQUE** |  | 60d | 2024-06-03 | 2024-08-10 |  |  |  |  |
| 2 | 1.1 | Inicio de Proyecto | milestone, manual | 0d | 2024-06-03 | 2024-06-03 |  |  |  | start no earlier than 2024-06-03 |
| 3 | 1.2 | **ACTIVIDADES PRELIMINARES** |  | 2d | 2024-06-03 | 2024-06-05 |  | 50d |  |  |
| 4 | 1.2.1 | Medición y ajuste de cantidades de obra |  | 1d | 2024-06-03 | 2024-06-04 | 2 | 43d | 0d |  |
| 5 | 1.2.2 | Replanteo de plano de conjunto |  | 1d | 2024-06-03 | 2024-06-04 | 4SS | 43d | 0d |  |
| 6 | 1.2.3 | Revisión de volumen de obra en presupuesto |  | 1d | 2024-06-03 | 2024-06-04 | 5SS | 43d | 0d |  |
| 7 | 1.2.4 | Inicio de acopio de materiales |  | 1d | 2024-06-04 | 2024-06-05 | 6 | 43d | 0d |  |
| 8 | 1.3 | **REHABILITACION DE ADMINISTRACIÓN Y BODEGA** |  | 47d | 2024-06-05 | 2024-07-29 |  | 0d |  |  |
| 9 | 1.3.1 | **DESMONTAJES** |  | 1d? | 2024-06-06 | 2024-06-07 |  |  |  |  |
| 10 | 1.3.1.1 | Desmontaje de sistema eléctrico existente en aulas, S.S. CRA, laboratorio, bodega, escenario, etc. |  | 3d | 2024-06-05 | 2024-06-08 | 7 | 54.38d | 0d | finish no earlier than 2024-06-05 |
| 11 | 1.3.1.2 | Desmontaje de aire acondicionado de ventana y entrega mediante acta al Director del Instituto |  | 5d | 2024-06-06 | 2024-06-11 | 10SS | 37.75d | 0d |  |
| 12 | 1.3.1.3 | Demolición de pared de bloque de concreto para apertura de puerta e incluir el desalojo |  | 3d | 2024-06-11 | 2024-06-15 | 11 | 37.75d | 0d | finish no earlier than 2024-06-04 |
| 13 | 1.3.1.4 | Desmontaje de división de plywood y desalojar | manual | 5d | 2024-07-15 | 2024-07-21 | 10 |  |  |  |
| 14 | 1.3.1.5 | Desmontaje de puerta metalica de una hoja y entregar mediante acta al Director | manual | 4d | 2024-07-15 | 2024-07-19 | 12 |  |  |  |
| 15 | 1.3.2 | **CUBIERTA DE TECHO Y ESTRUCTURA METÁLICA** |  | 15d | 2024-06-06 | 2024-06-23 |  | 0d |  |  |
| 16 | 1.3.2.1 | Limpieza, lijado y aplicación de 2 manos de pintura anticorrosiva de diferente color y 2 manos de pintura esmalte blanco en polines C 4" y 6" y viga metálica |  | 4d | 2024-06-08 | 2024-06-13 | 10 | 55.38d |  |  |
| 17 | 1.3.2.2 | PAREDES Y DIVISIONES | manual | 1d? | 2024-06-06 | 2024-06-07 |  |  |  |  |
| 18 | 1.3.2.3 | Pared de panel de cemento láminado con malla de fibra de vidrio polimerizada en ambas caras tipo Durock, forro a ambas caras estructura de tubo estructural de 4"x2" chapa 14, aplicar dos manos de pintura anticorrosiva y dos manos manos de pintura esmalte | manual | 15d | 2024-06-06 | 2024-06-23 |  |  |  |  |
| 19 | 1.3.3 | **VENTANAS** |  | 6d | 2024-06-23 | 2024-06-30 |  | 0d |  |  |
| 20 | 1.3.3.1 | Limpieza de estructura de aluminio y celosia de vidrio de ventanas existentes | manual | 4d | 2024-06-23 | 2024-06-27 | 18 |  |  |  |
| 21 | 1.3.3.2 | Limpieza, lijado y aplicación de 2 manos de pintura anticorrosiva de diferente color y 2 manos de pintura esmalte blanco en defensa metalica de hierro 1/2" |  | 6d | 2024-06-23 | 2024-06-30 | 18 | 28.75d |  |  |
| 22 | 1.3.4 | **CIELO FALSO** |  | 2d | 2024-06-23 | 2024-06-25 |  | 40.38d |  |  |
| 23 | 1.3.4.1 | Suministro e instalación de loseta de fibrolit tipo galaxy |  | 2d | 2024-06-23 | 2024-06-25 | 18 | 32.75d |  |  |
| 24 | 1.3.5 | **ACABADOS EN PAREDES** |  | 2d | 2024-06-14 | 2024-06-16 |  | 0d |  |  |
| 25 | 1.3.5.1 | Repello y afinado de cuadrados. Con mezcla prefabricada para repellos y afinados. | manual | 1d | 2024-06-14 | 2024-06-15 |  |  |  |  |
| 26 | 1.3.5.2 | Suministro y aplicación de pintura de agua acrílica lavable de primera calidad, acabado mate, incluye limpieza y preparación de paredes con base. Dos manos acabado uniforme. |  | 1d | 2024-06-15 | 2024-06-16 | 12 | 40.75d |  |  |

| ID | WBS | Task | Type | Duration | Start | Finish | Predecessors | Total slack | Free slack |
| --- | --- | --- | --- | --- | --- | --- | --- | --- | --- |
| 27 | 1.3.6 | **PUERTAS** |  | 41.38d | 2024-06-11 | 2024-07-29 |  | 0d |  |
| 28 | 1.3.6.1 | Suministro e instalación de puerta metálica 2 hojas DE 1.2 de ancho x 2.20 m de alto; Doble forro lamina de 1/16" estructura de 1"x1" chapa 14; Contramarco ang. 1 1/2"x 1 1/2" x 3/16"; Haladeras Ho. 3/4"; Chapa tipo parche de primera calidad, bisagras T/P |  | 6d | 2024-06-11 | 2024-06-18 | 12SS | 30.75d | 0d |
| 29 | 1.3.6.2 | PISO | manual | 1d? | 2024-06-11 | 2024-06-12 |  |  |  |
| 30 | 1.3.6.3 | Suministro e instalación de piso de concreto 180 kg/cm². Electromalla 6X6 CAL 9/9 E= 7.50cm en rampa para acceso a bodega | manual | 4d | 2024-06-18 | 2024-06-22 | 28 |  |  |
| 31 | 1.3.6.4 | Loseta de paso de 1.00m de ancho por 1.30m de largo concreto de 10cm de espesor con hierro 3/8" a 10cm ambos sentidos, sobre canaleta de aguas lluvias en acceso principal | manual | 4d | 2024-06-22 | 2024-06-27 | 30 |  |  |
| 32 | 1.3.6.5 | Suministro e instalación de gramoquin, incluir preparación de terreno y sembrar grama cuando el adoquin este instalado | manual | 12d | 2024-07-15 | 2024-07-29 | 31SS |  |  |
| 33 | 1.3.7 | **SISTEMAS ELÉCTRICOS E ILUMINACIÓN BODEGA** |  | 17d | 2024-06-23 | 2024-07-12 |  | 2d |  |
| 34 | 1.3.7.1 | Suministro e instalación de ST-AD de 12 Espacios, Barras de 125 AMP, MAIN de 80A/2P , incluye Puesta a Tierra del neutro y disyuntores térmicos. |  | 2d | 2024-06-23 | 2024-06-25 | 18 | 17.75d | 0d |
| 35 | 1.3.7.2 | Suministro e instalación de Sub-Alimentador desde ST-AD hasta TG existente compuesto por 2 THHN # 6 (F, F) + 1 THHN # 6 (N) + 1 THHN # 8 (T), canalizado en tubería conduit en áreas expuestas y tubería de PVC Conduit alto impacto de 1 1/2" en áreas subterr | manual | 2d | 2024-06-25 | 2024-06-27 | 34 |  |  |
| 36 | 1.3.7.3 | Suministro e instalación de salida de luz, canalizada con: Tuberia EMT y sus accesorios, cajas tipo pesado, incluye alambrado y puesta a tierra con 3 THNN #14 en tubería de 1/2"(conductor chaqueta, aislante verde y terminal de ojo). | manual | 2d | 2024-06-27 | 2024-06-30 | 35 |  |  |
| 37 | 1.3.7.4 | Suministro e instalación Luminaria Gabinete de 2´X4´ Tubos Led 3x18 Watts, 120v, de empotrar en Cielo Falso, difusor plástico Blanco cuadriculado Tipo Rejilla, Tubo T-8, Tipo Luz de día. | manual | 2d | 2024-06-30 | 2024-07-02 | 36 |  |  |
| 38 | 1.3.7.5 | Suministro e instalación de luminaria Led de 2'x18' exterior antipollvo IP65, G13, 120V, Sylvania o similar. Incluye tubos T8 de policarbonato. | manual | 2d | 2024-07-02 | 2024-07-04 | 37 |  |  |
| 39 | 1.3.7.6 | Suministro y montaje salida para toma doble aterrizado 20A, 120V, NEMA 5-20R uso general. Incluye caja rectangular 4"x2" pesada UL, 2 cables THHN # 12+1 CABLE THHN #14, Tecnoducto ø 1/2"; en caso de instalarse en forma superficial, se usara tuberia EMT y | manual | 2d | 2024-07-04 | 2024-07-06 | 38 |  |  |
| 40 | 1.3.7.7 | Suministro e Instalación de Equipo de Aire Acondicionado de 36,000 BTU, Tipo Mini Split, Inverter, Monofásico, Similar a LG o Equivalente, Refrigerante R410A, SEER de 16 o más, 240 Voltios, Incluye: drenaje, circuito de refrigeración, protección de tuberí | manual | 2d | 2024-07-05 | 2024-07-08 | 39 |  |  |
| 41 | 1.3.7.8 | Interruptor Sencillo con Terminal de Conexión a Tierra, 15 AMPS 120/ 277 Voltios, de Palanca y carcasa termoplástica resistente al alto impacto, color marfil, placa de acero inoxidable, caja rectangular de 4x2 " de hierro galvanizado pesada. | manual | 2d | 2024-07-08 | 2024-07-10 | 40 |  |  |
| 42 | 1.3.7.9 | Interruptor de Doble con terminal de conexión a tierra, 15 Amps 120/ 277 Voltios, de palanca y carcasa termoplástica resistente al alto impacto, color marfil, placa de acero inoxidable, caja rectangular de 4x2" de hierro galvanizado pesada. | manual | 2d | 2024-07-10 | 2024-07-12 | 41 |  |  |
| 43 | 1.4 | **ENTREGA DE OBRA** |  | 1d? | 2024-06-03 | 2024-06-04 |  |  |  |
| 44 | 1.4.1 | Entrega de Obra | manual | 1d | 2024-08-01 | 2024-08-02 |  |  |  |
